# Запуск АркаСтрой

Schedule from MS Project, 2022-06-17 to 2022-06-27, costs in ₽.

## Calendars

- Стандартный: Mon-Fri 09:00-13:00, 14:00-18:00; Sat-Sun off.

## Resources

| Resource | Rate |
| --- | --- |
| Кропотов | 1600 |
| Сотрудник заказчика |  |
| Еникеев | 2500 |
| Филиппов | 1600 |
| Кузнецов | 2500 |
| Чижик | 1600 |
| Виталик | 500 |
| Молочников | 2500 |

## Schedule

| ID | WBS | Task | Type | Duration | Start | Finish | Predecessors | Total slack | Free slack | Constraint | Resources | Work | Cost |
| --- | --- | --- | --- | --- | --- | --- | --- | --- | --- | --- | --- | --- | --- |
| 1 | 1 | **Запуск АркаСтрой** |  | 7d | 2022-06-17 | 2022-06-27 |  | 0d |  |  |  | 185h | 347,800 |
| 2 | 1.1 | **Решить технические проблемы и инциденты по текущей бизнес-логике** |  | 4d | 2022-06-17 | 2022-06-22 |  | 0d |  |  |  | 48h | 78,400 |
| 3 | 1.1.1 | Опредение БП, требующих поддержки (алгоритмы, отчеты, уведомления, задачи) | manual | 1d | 2022-06-17 | 2022-06-17 |  |  |  |  | Кропотов | 8h | 12,800 |
| 4 | 1.1.2 | Выявление инцидентов совместно с сотрудниками АркаСтрой | manual | 1d | 2022-06-17 | 2022-06-17 |  |  |  |  | Кропотов; Сотрудник заказчика | 16h | 12,800 |
| 5 | 1.1.3 | Постановка ТЗ на решение инцидентов |  | 1d | 2022-06-21 | 2022-06-21 |  | 3d | 0d | start no earlier than 2022-06-21 | Кропотов | 8h | 12,800 |
| 6 | 1.1.4 | Решение инцидентов | manual | 1d | 2022-06-22 | 2022-06-22 | 5 |  |  |  | Еникеев | 8h | 20,000 |
| 7 | 1.1.5 | Проверка работы Carabi 7 в офисе АркаСтрой | manual | 1d | 2022-06-21 | 2022-06-21 |  |  |  |  | Еникеев | 8h | 20,000 |
| 8 | 1.2 | **Обновить всех пользователей с Carabi 7 на Carabi X** |  | 4d | 2022-06-17 | 2022-06-22 |  | 0d |  |  |  | 48h | 84,000 |
| 9 | 1.2.1 | Анализ поведения всех ролей пользователей в Carabi 7 | manual | 1d | 2022-06-17 | 2022-06-17 |  |  |  |  | Кропотов | 8h | 12,800 |
| 10 | 1.2.2 | Настройка ролей в Carabi X | manual | 1d | 2022-06-20 | 2022-06-20 | 9 |  |  |  | Кропотов | 8h | 12,800 |
| 11 | 1.2.3 | Добавить таблицы из документов | manual | 1d | 2022-06-17 | 2022-06-17 |  |  |  |  | Кропотов | 8h | 12,800 |
| 12 | 1.2.4 | Составление плана обновления на Carabi X совместно с АркаСтрой | manual | 1d | 2022-06-21 | 2022-06-21 | 10 |  |  |  | Еникеев; Кропотов | 16h | 32,800 |
| 13 | 1.2.5 | Обучение пользователей и установка новой версии | manual | 1d | 2022-06-22 | 2022-06-22 | 12 |  |  |  | Кропотов | 8h | 12,800 |
| 14 | 1.3 | **Перенос файлового хранилища на Яндекс.Диск** |  | 4d | 2022-06-22 | 2022-06-27 |  | -3d | 0d |  |  | 89h | 185,400 |
| 15 | 1.3.1 | Анализ текущей файловой структуры | manual | 1d | 2022-06-22 | 2022-06-22 |  |  |  |  | Еникеев; Кропотов | 16h | 32,800 |
| 16 | 1.3.2 | Выбор технического решения |  | 1d | 2022-06-23 | 2022-06-23 | 15 | -4d | 0d |  | Молочников | 8h | 20,000 |
| 17 | 1.3.3 | Постановка ТЗ на реализацию переноса и хранения файлов на Яндекс.Диск |  | 2d | 2022-06-24 | 2022-06-27 | 16 | -4d | 0d |  | Молочников | 16h | 40,000 |
| 18 | 1.3.4 | **Реализация решения** |  | 1d | 2022-06-22 | 2022-06-22 | 17 | 0d |  |  | Еникеев | 25h | 59,800 |
| 19 | 1.3.4.1 | Аренда площадки INFO BOX (указать параметры) | manual | 2h | 2022-06-22 | 2022-06-22 |  |  |  |  | Молочников | 2h | 5,000 |
| 20 | 1.3.4.2 | Установка и настройка файл - сервера | manual | 4h | 2022-06-22 | 2022-06-22 |  |  |  |  | Кузнецов | 4h | 10,000 |
| 21 | 1.3.4.3 | Разработка и настройка брокера для обмена с Yandex диск | manual | 8h | 2022-06-22 | 2022-06-22 |  |  |  |  | Кузнецов | 8h | 20,000 |
| 22 | 1.3.4.4 | Перенастройка файлового хранилища | manual | 3h | 2022-06-22 | 2022-06-22 |  |  |  |  | Кропотов | 3h | 4,800 |
| 23 | 1.3.5 | **Составление плана перехода на Яндекс.Диск совместно с сотрудниками T-Company** |  | 1d | 2022-06-22 | 2022-06-22 | 18 | 0d |  |  | Еникеев; Кропотов; Сотрудник заказчика | 24h | 32,800 |
| 24 | 1.3.5.1 | Присоединить файлы в папки Заказов | manual | 1d? | 2022-06-22 | 2022-06-22 |  |  |  |  |  |  |  |
| 25 | 1.3.6 | Переход на Яндекс.Диск |  | 1d | 2022-06-23 | 2022-06-23 | 23 | 2d |  |  |  |  |  |
